# ANDITEL

Schedule from MS Project, 2014-01-02 to 2014-02-07, costs in $.
Hewlett-Packard Company

## Calendars

- Estándar: Mon-Fri 09:00-13:00, 15:00-19:00; Sat-Sun off.

## Resources

| Resource |
| --- |
| Impresiones |
| Coordinador logistico |
| Video Beam |

## Schedule

| ID | WBS | Task | Duration | Start | Finish | Predecessors | Total slack | Constraint | Resources | Work | Cost |
| --- | --- | --- | --- | --- | --- | --- | --- | --- | --- | --- | --- |
| 1 | 1 | Suscripcion del contrato | 1d? | 2014-01-02 | 2014-01-02 |  | 0d | start no earlier than 2014-01-02 |  |  |  |
| 2 | 2 | **ETAPA 1: Solicitud de certificacion de presencia de comunidades etnicas** | 25d? | 2014-01-03 | 2014-02-06 | 1 | 0d |  | Impresiones | 200h | 7,150,200 |
| 3 | 2.1 | **Apoyo logistico a la Direccion de Consulta previa para la visita de verificacion** | 25d? | 2014-01-03 | 2014-02-06 |  | 0d |  | Coordinador logistico | 200h | 7,150,000 |
| 4 | 2.1.1 | Coordinacion con la Direccion de Consulta previa, para el desarrollo de posibles visitas de verificacion | 4d | 2014-01-03 | 2014-01-08 |  | 0d |  |  |  |  |
| 5 | 2.1.2 | **Visita de verificacion torre Togoroma** | 8d | 2014-01-09 | 2014-01-20 | 4 | 0d |  |  |  |  |
| 6 | 2.1.2.1 | Entrada a la zona de influencia del proyecto | 3d | 2014-01-09 | 2014-01-13 |  | 0d |  |  |  |  |
| 7 | 2.1.2.2 | Recorrido por el area de influencia | 2d | 2014-01-14 | 2014-01-15 | 6 | 0d |  |  |  |  |
| 8 | 2.1.2.3 | Salida del Resguardo Togoroma | 3d | 2014-01-16 | 2014-01-20 | 7 | 0d |  |  |  |  |
| 9 | 2.1.3 | **Visita de verificacion Torre Pana Pana** | 4d? | 2014-01-21 | 2014-01-24 | 5 | 0d |  |  |  |  |
| 10 | 2.1.3.1 | Entrada a la zona de influencia del proyecto | 2d | 2014-01-21 | 2014-01-22 |  | 0d |  |  |  |  |
| 11 | 2.1.3.2 | Recorrido por el area de influencia | 1d? | 2014-01-23 | 2014-01-23 | 10 | 0d |  |  |  |  |
| 12 | 2.1.3.3 | Salida del area de influencia | 1d? | 2014-01-24 | 2014-01-24 | 11 | 0d |  |  |  |  |
| 13 | 2.1.4 | **Visita de verificacion Torre el Encanto** | 3d? | 2014-01-27 | 2014-01-29 | 9 | 0d |  |  |  |  |
| 14 | 2.1.4.1 | Entrada a la zona de influencia del proyecto | 1d? | 2014-01-27 | 2014-01-27 |  | 0d |  |  |  |  |
| 15 | 2.1.4.2 | Recorrido por el area de influencia del proyecto | 1d? | 2014-01-28 | 2014-01-28 | 14 | 0d |  |  |  |  |
| 16 | 2.1.4.3 | Salida del area de influencia del proyecto | 1d? | 2014-01-29 | 2014-01-29 | 15 | 0d |  |  |  |  |
| 17 | 2.1.5 | **Visita de verificacion Torre Papunaua** | 3d? | 2014-01-30 | 2014-02-03 | 13 | 0d |  |  |  |  |
| 18 | 2.1.5.1 | Entrada a la zona de influencia del proyecto | 1d? | 2014-01-30 | 2014-01-30 |  | 0d |  |  |  |  |
| 19 | 2.1.5.2 | Recorrido por el area de influencia del proyecto | 1d? | 2014-01-31 | 2014-01-31 | 18 | 0d |  |  |  |  |
| 20 | 2.1.5.3 | Salida del area de influencia del proyecto | 1d? | 2014-02-03 | 2014-02-03 | 19 | 0d |  |  |  |  |
| 21 | 2.1.6 | **Visita de verificacion Torre Puerto Maria Manteca** | 3d? | 2014-02-04 | 2014-02-06 | 17 | 0d |  |  |  | 2,000,000 |
| 22 | 2.1.6.1 | Entrada a la zona de influencia del proyecto | 1d? | 2014-02-04 | 2014-02-04 |  | 0d |  |  |  |  |
| 23 | 2.1.6.2 | Recorrido por el area de influencia del proyecto | 1d? | 2014-02-05 | 2014-02-05 | 22 | 0d |  |  |  |  |
| 24 | 2.1.6.3 | Salida del area de influencia del proyecto | 1d? | 2014-02-06 | 2014-02-06 | 23 | 0d |  | Impresiones |  | 2,000,000 |

| ID | WBS | Task | Duration | Start | Finish | Predecessors | Total slack |
| --- | --- | --- | --- | --- | --- | --- | --- |
| 25 | 3 | **ETAPA 2: Coordinacion y preparacion** | 1d? | 2014-02-07 | 2014-02-07 | 2 | 0d |
| 26 | 3.1 | Convocatoria por parte de la DCP a comunidades y empresa | 1d? | 2014-02-07 | 2014-02-07 |  | 0d |
